# GSTOP_rev 1

Schedule from MS Project, 2004-10-20 to 2006-06-02.
GSTOP Project Plan

## Calendars

- Standard: Mon-Fri 08:00-12:00, 13:00-17:00; Sat-Sun off.

## Resources

| Resource |
| --- |
| Sgoodman |
| Smclellan |
| Jfrost |
| GTG |
| GTG Exec Comm |
| Symbol Subteam |
| NWCG Training Team |
| GSTOP Team |
| subteam |
| NWCG member agencies |
| reviewers |
| GSTOP Team; GTG Exec Comm |
| subteam(s) |
| all concerned/impacted parties |
| business community |
| GSTOP Team; GTG; GTAG; |
| GSTOP Team; GTG |
| GSTOP Team; GTAG; |
| GSTOP Team; GTAG; somes other reviewers |
| GSTOP Team; GTG; GTAG |
| some other reviewers |
| subteams and Sue |
| gstop |
| GSTOP Team; Indepdent reviewer |
| subteams |
| Victoria |
| ; deb epps |
| BLM publication shop |
| GTG standards committee |
| Mary Kwart |
| Internet Search |
| Military |
| etc. |
| survey GISTs |
| Plans Sections (Mary Kwart) |
| Documents Sections |
| Business Lead |
| FGDC |
| NARA |
| agency guidance |
| TBD |
| GeoMAC |
| NPS I&M |
| NPS Focus |
| Sub-Team |
| Other "team" environs (e.g. military) |
| survey? Mary Kwart? |
| field teams |
| IRMWT |
| IRWMT |
| Project Mgr |
| Sean Triplett |
| IMT Teams |

## Schedule

| ID | WBS | Task | Duration | Start | Finish | Predecessors | Baseline start | Baseline finish | Baseline duration | Total slack | Free slack | Constraint | Resources | Work | Text1 |
| --- | --- | --- | --- | --- | --- | --- | --- | --- | --- | --- | --- | --- | --- | --- | --- |
| 1 | 1 | **GSTOP Project Initiation** | 105d? | 2004-10-20 | 2005-03-15 |  | 2004-11-30 | 2004-12-31 | 23d? | 305d | 0d |  | IRMWT | 4384h |  |
| 2 | 1.1 | **Initiate the GSTOP Project** | 98d | 2004-10-20 | 2005-03-04 |  | 2004-11-30 | 2004-12-01 | 2d | 312d |  |  | GTG Exec Comm | 1576h |  |
| 3 | 1.1.1 | GSTOP Executive Committee Formed | 6d | 2004-12-01 | 2004-12-08 |  | 2004-12-01 | 2004-12-01 | 1d | 374d |  | finish no earlier than 2004-12-08 | IRWMT | 48h |  |
| 4 | 1.1.2 | GSTOP Project Manager Identified | 1d | 2004-10-20 | 2004-10-20 |  | 2004-11-30 | 2004-12-01 | 2d | 409d |  | finish no earlier than 2004-10-20 | GTG Exec Comm | 8h |  |
| 5 | 1.1.3 | GSTOP Project Charter Approved | 1d | 2004-12-01 | 2004-12-01 |  | 2004-12-01 | 2004-12-01 | 1d | 379d |  |  | NWCG member agencies | 8h | Project Charter |
| 6 | 1.1.4 | GSTOP Project Funding Secured | 68d | 2004-12-01 | 2005-03-04 |  | 2004-12-01 | 2004-12-01 | 1d | 312d |  | finish no earlier than 2005-03-04 | NWCG member agencies | 544h |  |
| 7 | 1.1.5 | GSTOP Project Team Identified | 23d | 2004-12-01 | 2004-12-31 |  | 2004-12-01 | 2004-12-01 | 1d | 357d |  | finish no earlier than 2004-12-31 | GTG Exec Comm | 184h | Team Roster |
| 8 | 1.2 | **Form the GSTOP Team** | 33d? | 2004-12-15 | 2005-01-28 |  | 2004-12-01 | 2004-12-31 | 22d? | 337d |  |  | GTG Exec Comm | 576h |  |
| 9 | 1.2.1 | GSTOP Project Business Lead Identified | 29d | 2004-12-15 | 2005-01-24 |  | 2004-12-31 | 2004-12-31 | 0d | 341d |  | finish no earlier than 2005-01-24 | Project Mgr | 232h |  |
| 10 | 1.2.2 | Define and Assign Project Subteams and Leads | 5d? | 2005-01-24 | 2005-01-28 |  | 2004-12-01 | 2004-12-01 | 1d? | 337d |  | start no earlier than 2005-01-24 | Project Mgr | 40h |  |
| 11 | 1.2.3 | Develop Project Team Operating Principles & Guidelines | 5d? | 2005-01-24 | 2005-01-28 |  | 2004-12-01 | 2004-12-01 | 1d? | 337d |  | start no earlier than 2005-01-24 | Project Mgr | 40h | Operating Principles Doc |
| 12 | 1.3 | **Develop the GSTOP Project Management Plans** | 75d? | 2004-12-01 | 2005-03-15 |  | 2004-12-01 | 2004-12-06 | 4d? | 305d |  |  |  | 1384h |  |
| 13 | 1.3.1 | Review Charter and resolve any ambiguities/issues | 51d? | 2005-01-03 | 2005-03-14 |  | 2004-12-01 | 2004-12-01 | 1d? | 306d |  | start no earlier than 2005-01-03 | Project Mgr | 408h | Updated Charter |
| 14 | 1.3.2 | Develop Intial Project Work Plan | 50d? | 2005-01-04 | 2005-03-14 |  | 2004-12-01 | 2004-12-01 | 1d? | 306d |  | start no earlier than 2005-01-04 | Project Mgr | 400h | Work Plan |
| 15 | 1.3.3 | Develop Intial Project Communication Plan | 72d | 2004-12-06 | 2005-03-15 |  | 2004-12-06 | 2004-12-06 | 1d | 305d |  | finish no earlier than 2005-03-15 | Business Lead | 576h | Communication Plan |
| 16 | 1.3.4 | Develop Intial Project Responsibility Matrix | 1d? | 2004-12-01 | 2004-12-01 |  | 2004-12-01 | 2004-12-01 | 1d? | 379d |  |  |  |  |  |
| 17 | 1.3.5 | Develop Intial Project Resource Plan | 31d? | 2005-01-31 | 2005-03-14 |  | 2004-12-01 | 2004-12-01 | 1d? | 306d |  | start no earlier than 2005-01-31 |  |  | Staffing Plan |
| 18 | 1.4 | **Develop the GSTOP Communication and Management Structures** | 65d? | 2004-12-01 | 2005-03-01 |  | 2004-12-01 | 2004-12-01 | 1d? | 315d |  |  |  | 8h |  |
| 19 | 1.4.1 | Research 4 websites and select option for public communications | 1d? | 2004-12-01 | 2004-12-01 |  | 2004-12-01 | 2004-12-01 | 1d? | 379d |  |  |  |  |  |
| 20 | 1.4.2 | Create GSTOP private team workspace | 1d? | 2004-12-01 | 2004-12-01 |  | 2004-12-01 | 2004-12-01 | 1d? | 379d |  |  | Sean Triplett | 8h | Accessible Workspace |
| 21 | 1.4.3 | Develop Project Status Report Template | 42d? | 2005-01-03 | 2005-03-01 |  | 2004-12-01 | 2004-12-01 | 1d? | 315d |  | start no earlier than 2005-01-03 |  |  |  |
| 22 | 2 | **GSTOP Business Requirements** | 13d? | 2005-03-15 | 2005-04-01 | 1 | 2004-12-31 | 2005-01-18 | 13d? | 305d |  |  | GSTOP Team | 304h |  |
| 23 | 2.1 | **Incident GIS Standard Symbology Requirements** | 4d? | 2005-03-16 | 2005-03-21 |  | 2004-12-31 | 2005-01-05 | 4d? | 314d |  |  |  | 64h |  |
| 24 | 2.1.1 | **Establish Symbols Sub-Team business practices** | 1d? | 2005-03-16 | 2005-03-16 |  | 2004-12-31 | 2004-12-31 | 1d? | 317d |  |  |  |  |  |
| 25 | 2.1.1.1 | **Develop a Symbol Sub-team Communication Plan** | 1d? | 2005-03-16 | 2005-03-16 |  | 2004-12-31 | 2004-12-31 | 1d? | 317d |  |  |  |  | Communication Plan |
| 26 | 2.1.1.1.1 | Define ground-rules for Sub-Team (internal) communication | 1d? | 2005-03-16 | 2005-03-16 |  | 2004-12-31 | 2004-12-31 | 1d? | 317d |  |  |  |  |  |
| 27 | 2.1.1.1.2 | Define ground-rules for communication between the Symbol Sub-Team and other GSTOP Sub-Teams | 1d? | 2005-03-16 | 2005-03-16 |  | 2004-12-31 | 2004-12-31 | 1d? | 317d |  |  |  |  |  |
| 28 | 2.1.1.1.3 | Define ground rules for communication between the Sub-Team and entities outside of the GSTOP Project | 1d? | 2005-03-16 | 2005-03-16 |  | 2004-12-31 | 2004-12-31 | 1d? | 317d |  |  |  |  |  |
| 29 | 2.1.1.1.4 | Establish a process and schedule for Sub-Team (internal) progress report updates | 1d? | 2005-03-16 | 2005-03-16 |  | 2004-12-31 | 2004-12-31 | 1d? | 317d |  |  |  |  |  |
| 30 | 2.1.1.1.5 | Establish a process and schedule for Sub-Team progress report updates to the GSTOP Team | 1d? | 2005-03-16 | 2005-03-16 |  | 2004-12-31 | 2004-12-31 | 1d? | 317d |  |  |  |  |  |

| ID | WBS | Task | Duration | Start | Finish | Baseline start | Baseline finish | Baseline duration | Total slack | Text1 |
| --- | --- | --- | --- | --- | --- | --- | --- | --- | --- | --- |
| 31 | 2.1.1.2 | **Establish Review Processes** | 1d? | 2005-03-16 | 2005-03-16 | 2004-12-31 | 2004-12-31 | 1d? | 317d | Symbol Set Review Process |
| 32 | 2.1.1.2.1 | Establish a process for Sub-Team (internal) review of potential symbols | 1d? | 2005-03-16 | 2005-03-16 | 2004-12-31 | 2004-12-31 | 1d? | 317d |  |
| 33 | 2.1.1.2.2 | Establish a process for Sub-Team (internal) review of the draft standard symbols | 1d? | 2005-03-16 | 2005-03-16 | 2004-12-31 | 2004-12-31 | 1d? | 317d |  |
| 34 | 2.1.1.2.3 | Establish a process for peer reviews | 1d? | 2005-03-16 | 2005-03-16 | 2004-12-31 | 2004-12-31 | 1d? | 317d |  |
| 35 | 2.1.1.2.4 | Establish a process for periodic GSTOP Team reviews | 1d? | 2005-03-16 | 2005-03-16 | 2004-12-31 | 2004-12-31 | 1d? | 317d |  |
| 36 | 2.1.1.2.5 | Establish a process for reviewing the final report | 1d? | 2005-03-16 | 2005-03-16 | 2004-12-31 | 2004-12-31 | 1d? | 317d |  |
| 37 | 2.1.1.3 | **Establish Change processes** | 1d? | 2005-03-16 | 2005-03-16 | 2004-12-31 | 2004-12-31 | 1d? | 317d | Symbol Set Change Process |
| 38 | 2.1.1.3.1 | Establish a process for additions/deletions of potential symbols mid-stream through the Project | 1d? | 2005-03-16 | 2005-03-16 | 2004-12-31 | 2004-12-31 | 1d? | 317d |  |
| 39 | 2.1.1.3.2 | Establish a change process for the additions/deletion of standard symbols after the final recommendation has been submitted and prior to completion of the GSTOP project | 1d? | 2005-03-16 | 2005-03-16 | 2004-12-31 | 2004-12-31 | 1d? | 317d |  |
| 40 | 2.1.1.3.3 | Establish a change process for the additions/deletion of standard symbols after the completion of the GSTOP project | 1d? | 2005-03-16 | 2005-03-16 | 2004-12-31 | 2004-12-31 | 1d? | 317d |  |
| 41 | 2.1.2 | **Establish symbol evaluation methods** | 1d? | 2005-03-16 | 2005-03-16 | 2004-12-31 | 2004-12-31 | 1d? | 317d |  |
| 42 | 2.1.2.1 | Define method for evaluating marker symbols | 1d? | 2005-03-16 | 2005-03-16 | 2004-12-31 | 2004-12-31 | 1d? | 317d |  |
| 43 | 2.1.2.2 | Define method for evaluating line symbols | 1d? | 2005-03-16 | 2005-03-16 | 2004-12-31 | 2004-12-31 | 1d? | 317d |  |
| 44 | 2.1.2.3 | Define method for evaluating fill symbols | 1d? | 2005-03-16 | 2005-03-16 | 2004-12-31 | 2004-12-31 | 1d? | 317d |  |
| 45 | 2.1.2.4 | Conduct a final review of evaluation methods | 1d? | 2005-03-16 | 2005-03-16 | 2004-12-31 | 2004-12-31 | 1d? | 317d | Standard Symbol Evaluation Methodology |
| 46 | 2.1.3 | **Define criteria for the acceptance of symbols as standards** | 1d? | 2005-03-16 | 2005-03-16 | 2004-12-31 | 2004-12-31 | 1d? | 317d |  |
| 47 | 2.1.3.1 | Develop acceptance criteria for marker symbols | 1d? | 2005-03-16 | 2005-03-16 | 2004-12-31 | 2004-12-31 | 1d? | 317d |  |
| 48 | 2.1.3.2 | Develop acceptance criteria for line symbols | 1d? | 2005-03-16 | 2005-03-16 | 2004-12-31 | 2004-12-31 | 1d? | 317d |  |
| 49 | 2.1.3.3 | Develop acceptance criteria for fill symbols | 1d? | 2005-03-16 | 2005-03-16 | 2004-12-31 | 2004-12-31 | 1d? | 317d |  |
| 50 | 2.1.3.4 | Conduct a final review of selection criteria | 1d? | 2005-03-16 | 2005-03-16 | 2004-12-31 | 2004-12-31 | 1d? | 317d | Standard Symbol Acceptance Criteria |
| 51 | 2.1.4 | **Establish file format for symbols** | 1d? | 2005-03-16 | 2005-03-16 | 2004-12-31 | 2004-12-31 | 1d? | 317d |  |
| 52 | 2.1.4.1 | Define acceptable formats of symbols for evaluation | 1d? | 2005-03-16 | 2005-03-16 | 2004-12-31 | 2004-12-31 | 1d? | 317d |  |
| 53 | 2.4.1.2 | Define format of recommended standard symbols | 1d? | 2005-03-16 | 2005-03-16 | 2004-12-31 | 2004-12-31 | 1d? | 317d |  |
| 54 | 2.1.5 | **Develop a list of symbols to be evaluated for acceptance as draft standards** | 1d? | 2005-03-16 | 2005-03-16 | 2004-12-31 | 2004-12-31 | 1d? | 317d |  |
| 55 | 2.1.5.1 | Collect Fire mapping symbols from the Fireline Handbook | 1d? | 2005-03-16 | 2005-03-16 | 2004-12-31 | 2004-12-31 | 1d? | 317d | symbol image files |
| 56 | 2.1.5.2 | Collect Fire mapping symbols suggestions from the 5 federal fire management agencies (FS, BLM, NPS, FWS, BIA) and state agencies via the NWCG Geospatial Task Group (GTG) | 1d? | 2005-03-16 | 2005-03-16 | 2004-12-31 | 2004-12-31 | 1d? | 317d | symbol image files |
| 57 | 2.1.5.3 | Collect Fire mapping symbols from HSA (FEMA), FAA, and DOD | 1d? | 2005-03-16 | 2005-03-16 | 2004-12-31 | 2004-12-31 | 1d? | 317d | symbol image files |
| 58 | 2.1.5.4 | Document potential sources for additional fire mapping symbols | 1d? | 2005-03-16 | 2005-03-16 | 2004-12-31 | 2004-12-31 | 1d? | 317d | List of data sources |
| 59 | 2.1.5.5 | Compile symbols into a single potential symbol set | 1d? | 2005-03-16 | 2005-03-16 | 2004-12-31 | 2004-12-31 | 1d? | 317d | Set of potential standard symbols |

| ID | WBS | Task | Duration | Start | Finish | Predecessors | Baseline start | Baseline finish | Baseline duration | Total slack | Free slack | Resources | Work | Text1 |
| --- | --- | --- | --- | --- | --- | --- | --- | --- | --- | --- | --- | --- | --- | --- |
| 60 | 2.1.6 | **Determine the draft standard marker symbols** | 1d? | 2005-03-16 | 2005-03-16 |  | 2004-12-31 | 2004-12-31 | 1d? | 317d |  |  | 16h |  |
| 61 | 2.1.6.1 | Evaluate each potential marker symbol against the marker symbol selection criteria | 1d? | 2005-03-16 | 2005-03-16 |  | 2004-12-31 | 2004-12-31 | 1d? | 317d |  |  |  | Marker Symbol Evaluation Document |
| 62 | 2.1.6.2 | Selection the draft standard marker symbols | 1d? | 2005-03-16 | 2005-03-16 |  | 2004-12-31 | 2004-12-31 | 1d? | 317d |  | Symbol Subteam | 8h | Draft list of selected marker symbols |
| 63 | 2.1.6.3 | Conduct a completeness review of the draft standard marker symbols | 1d? | 2005-03-16 | 2005-03-16 |  | 2004-12-31 | 2004-12-31 | 1d? | 317d |  | Symbol Subteam | 8h | Draft Standard Marker Symbols document |
| 64 | 2.1.7 | **Determine the draft standard line symbols** | 1d? | 2005-03-16 | 2005-03-16 |  | 2004-12-31 | 2004-12-31 | 1d? | 317d |  |  | 16h |  |
| 65 | 2.1.7.1 | Evaluate each potential line symbol against the line symbol selection criteria | 1d? | 2005-03-16 | 2005-03-16 |  | 2004-12-31 | 2004-12-31 | 1d? | 317d |  |  |  | Line Symbol Evaluation Document |
| 66 | 2.1.7.2 | Select the draft standard line symbols | 1d? | 2005-03-16 | 2005-03-16 |  | 2004-12-31 | 2004-12-31 | 1d? | 317d |  | Symbol Subteam | 8h | Draft list of selected Line symbols |
| 67 | 2.1.7.3 | Conduct a completeness review of the draft standard line symbols | 1d? | 2005-03-16 | 2005-03-16 |  | 2004-12-31 | 2004-12-31 | 1d? | 317d |  | Symbol Subteam | 8h | Draft Standard Line Symbols document |
| 68 | 2.1.8 | **Determine the draft standard fill symbols** | 1d? | 2005-03-16 | 2005-03-16 |  | 2004-12-31 | 2004-12-31 | 1d? | 317d |  |  | 16h |  |
| 69 | 2.1.8.1 | Evaluate each potential fill symbol against the fill symbol selection criteria | 1d? | 2005-03-16 | 2005-03-16 |  | 2004-12-31 | 2004-12-31 | 1d? | 317d |  |  |  | Fill Symbol Evaluation Document |
| 70 | 2.1.8.2 | Select the draft standard fill symbols | 1d? | 2005-03-16 | 2005-03-16 |  | 2004-12-31 | 2004-12-31 | 1d? | 317d |  | Symbol Subteam | 8h | Draft list of selected fill symbols |
| 71 | 2.1.8.3 | Conduct a completeness review of the draft standard fill symbols | 1d? | 2005-03-16 | 2005-03-16 |  | 2004-12-31 | 2004-12-31 | 1d? | 317d |  | Symbol Subteam | 8h | Draft Standard fill Symbols document |
| 72 | 2.1.9 | **Conduct initial peer review of the draft standard marker, line, and fill symbols** | 4d? | 2005-03-16 | 2005-03-21 |  | 2004-12-31 | 2005-01-05 | 4d? | 314d |  |  |  |  |
| 73 | 2.1.9.1 | Prepare draft standard symbols for initial peer review | 1d? | 2005-03-16 | 2005-03-16 |  | 2004-12-31 | 2004-12-31 | 1d? | 317d |  |  |  | Initial Peer Review Package |
| 74 | 2.1.9.2 | Submit the draft standard symbols to the 5 federal fire management agencies and State agencies via the NWCG Geospatial Task Group (GTG); and to the HSA (FEMA), FAA, DOD, and GSTOP Team for peer review | 1d? | 2005-03-16 | 2005-03-16 |  | 2004-12-31 | 2004-12-31 | 1d? | 314d | 0d |  |  | Submission Report |
| 75 | 2.1.9.3 | Review feedback of initial peer review | 1d? | 2005-03-17 | 2005-03-17 | 74 | 2005-01-03 | 2005-01-03 | 1d? | 314d | 0d |  |  | Initial Peer Review Document |
| 76 | 2.1.9.4 | Identify required changes to draft standard symbols based on the initial peer review feedback | 1d? | 2005-03-18 | 2005-03-18 | 75 | 2005-01-04 | 2005-01-04 | 1d? | 314d | 0d |  |  | List of required symbol changes |
| 77 | 2.1.9.5 | Make required changes, as identified, to draft standard symbols | 1d? | 2005-03-21 | 2005-03-21 | 76 | 2005-01-05 | 2005-01-05 | 1d? | 314d |  |  |  | Initial updated Symbols list |
| 78 | 2.1.10 | **Conduct final peer review of the draft standard marker, line and fill symbols** | 1d? | 2005-03-16 | 2005-03-16 |  | 2004-12-31 | 2004-12-31 | 1d? | 317d |  |  | 8h |  |
| 79 | 2.1.10.1 | Prepare draft standard symbols for final peer review | 1d? | 2005-03-16 | 2005-03-16 |  | 2004-12-31 | 2004-12-31 | 1d? | 317d |  |  |  | Final Peer Review Package |
| 80 | 2.1.10.2 | Submit the draft standard symbols to the 5 federal fire management agencies and State agencies via the NWCG Geospatial Task Group (GTG); and to the HSA (FEMA), FAA, DOD, and GSTOP Team for peer review | 1d? | 2005-03-16 | 2005-03-16 |  | 2004-12-31 | 2004-12-31 | 1d? | 317d |  |  |  | Submission Report |
| 81 | 2.1.10.3 | Review feedback of the final peer review | 1d? | 2005-03-16 | 2005-03-16 |  | 2004-12-31 | 2004-12-31 | 1d? | 317d |  |  |  | Final Peer Review Document |
| 82 | 2.1.10.4 | Identify required changes to draft standard symbols based on the final peer review feedback | 1d? | 2005-03-16 | 2005-03-16 |  | 2004-12-31 | 2004-12-31 | 1d? | 317d |  |  |  | List of required symbol changes |
| 83 | 2.1.10.5 | Make required changes, as identified, to draft standard symbols | 1d? | 2005-03-16 | 2005-03-16 |  | 2004-12-31 | 2004-12-31 | 1d? | 317d |  |  |  | final updated symbols list |
| 84 | 2.1.10.6 | Ratify the final draft standard symbols | 1d? | 2005-03-16 | 2005-03-16 |  | 2004-12-31 | 2004-12-31 | 1d? | 317d |  | Symbol Subteam | 8h | Final Draft Standard Symbols List |

| ID | WBS | Task | Duration | Start | Finish | Predecessors | Baseline start | Baseline finish | Baseline duration | Total slack | Free slack | Resources | Work | Text1 |
| --- | --- | --- | --- | --- | --- | --- | --- | --- | --- | --- | --- | --- | --- | --- |
| 85 | 2.1.11 | **Finalize recommendation of standard Fire Mapping symbols** | 1d? | 2005-03-16 | 2005-03-16 |  | 2004-12-31 | 2004-12-31 | 1d? | 317d |  |  | 8h |  |
| 86 | 2.1.11.1 | Create a report recommending the adoption of the draft standard symbols | 1d? | 2005-03-16 | 2005-03-16 |  | 2004-12-31 | 2004-12-31 | 1d? | 317d |  |  |  | Recommendation Report |
| 87 | 2.1.11.2 | Conduct a review of the report | 1d? | 2005-03-16 | 2005-03-16 |  | 2004-12-31 | 2004-12-31 | 1d? | 317d |  | Symbol Subteam | 8h | Finalized Recommendation Report |
| 88 | 2.1.11.3 | Submit the report to GSTOP-PM | 1d | 2005-03-16 | 2005-03-16 |  | 2004-12-31 | 2004-12-31 | 1d | 317d |  |  |  | Report Submission |
| 89 | 2.2 | **Incident GIS Standard Naming Conventions Requirements** | 12d? | 2005-03-16 | 2005-03-31 |  | 2004-12-31 | 2005-01-06 | 5d? | 306d |  |  |  |  |
| 90 | 2.2.1 | **Define Information Needs (What do we need to gather?)** | 1d? | 2005-03-16 | 2005-03-16 |  | 2004-12-31 | 2004-12-31 | 1d? | 317d |  |  |  |  |
| 91 | 2.2.1.1 | Set objectives for work plan | 1d? | 2005-03-16 | 2005-03-16 |  |  |  |  | 317d |  |  |  | document |
| 92 | 2.2.1.2 | Define ground rules for sub team | 1d? | 2005-03-16 | 2005-03-16 |  |  |  |  | 317d |  |  |  | document |
| 93 | 2.2.1.3 | Define common ground with other sub teams | 1d? | 2005-03-16 | 2005-03-16 |  |  |  |  | 317d |  |  |  | communications agreement |
| 94 | 2.2.2 | **Collect Information** | 1d? | 2005-03-16 | 2005-03-16 |  | 2005-01-03 | 2005-01-03 | 1d? | 312d |  |  |  |  |
| 95 | 2.2.2.1 | Collect existing naming and filing conventions from GIST's attached to IMT's | 1d? | 2005-03-16 | 2005-03-16 |  |  |  |  | 312d | 0d |  |  | physical examples |
| 96 | 2.2.3 | **Conduct Analysis** | 2d? | 2005-03-17 | 2005-03-18 | 95 | 2005-01-04 | 2005-01-04 | 1d? | 312d |  |  |  |  |
| 97 | 2.2.3.1 | Review strengths & weaknesses of existing methodologies | 1d? | 2005-03-17 | 2005-03-17 |  |  |  |  | 312d | 0d |  |  | shared |
| 98 | 2.2.3.2 | Resolve overlap and conflicts | 1d? | 2005-03-18 | 2005-03-18 | 97 |  |  |  | 312d | 0d |  |  |  |
| 99 | 2.2.4 | **Develop Preliminary Requirements Specifications** | 2d? | 2005-03-21 | 2005-03-22 | 98 | 2005-01-05 | 2005-01-05 | 1d? | 312d |  |  |  |  |
| 100 | 2.2.4.1 | Draft naming convention guidelines | 1d? | 2005-03-21 | 2005-03-21 |  |  |  |  | 312d | 0d |  |  |  |
| 101 | 2.2.4.2 | Draft directory structure guidelines | 1d? | 2005-03-22 | 2005-03-22 | 100 |  |  |  | 312d | 0d |  |  |  |
| 102 | 2.2.5 | **Requirements Review and Validation** | 1d? | 2005-03-23 | 2005-03-23 | 101 | 2005-01-06 | 2005-01-06 | 1d? | 312d |  |  |  |  |
| 103 | 2.2.5.1 | Post draft guidelines for inter team review | 1d? | 2005-03-23 | 2005-03-23 |  |  |  |  | 312d |  |  |  |  |
| 104 | 2.2.5.2 | Edit draft guidelines based on input | 1d? | 2005-03-23 | 2005-03-23 |  |  |  |  | 312d |  |  |  |  |
| 105 | 2.2.5.3 | Post draft guidelines for external review | 1d? | 2005-03-23 | 2005-03-23 |  |  |  |  | 312d |  |  |  |  |
| 106 | 2.2.5.4 | Edit draft guidelines based on input | 1d? | 2005-03-23 | 2005-03-23 |  |  |  |  | 312d |  |  |  |  |
| 107 | 2.2.6 | **Prepare Sample Documents** | 1d? | 2005-03-16 | 2005-03-16 |  |  |  |  | 317d |  |  |  |  |
| 108 | 2.2.6.1 | Prepare Naming conventions | 1d? | 2005-03-16 | 2005-03-16 |  |  |  |  | 317d |  |  |  |  |
| 109 | 2.2.6.2 | Develop Directory structure | 1d? | 2005-03-16 | 2005-03-16 |  |  |  |  | 317d |  |  |  |  |
| 110 | 2.2.6.3 | Prepare Methods of work | 1d? | 2005-03-16 | 2005-03-16 |  |  |  |  | 317d |  |  |  |  |

| ID | WBS | Task | Duration | Start | Finish | Predecessors | Baseline start | Baseline finish | Baseline duration | Total slack | Free slack |
| --- | --- | --- | --- | --- | --- | --- | --- | --- | --- | --- | --- |
| 111 | 2.2.7 | **Sample Documents Review and Validation** | 12d? | 2005-03-16 | 2005-03-31 |  |  |  |  | 306d |  |
| 112 | 2.2.7.1 | Post sample documents for inter team review | 1d? | 2005-03-16 | 2005-03-16 |  |  |  |  | 317d |  |
| 113 | 2.2.7.2 | Edit sample documents based on input | 1d? | 2005-03-16 | 2005-03-16 |  |  |  |  | 317d |  |
| 114 | 2.2.7.3 | Post sample documents for external review | 5d? | 2005-03-16 | 2005-03-22 |  | 2004-12-31 | 2005-01-17 | 12d? | 313d |  |
| 115 | 2.2.7.4 | Edit sample documents based on input | 12d? | 2005-03-16 | 2005-03-31 |  | 2004-12-31 | 2005-01-05 | 4d? | 306d |  |
| 116 | 2.3 | **Incident GIS Standard Product Definitions Requirements** | 8d? | 2005-03-16 | 2005-03-25 |  |  |  |  | 310d |  |
| 117 | 2.3.1 | **Define Information Needs (What do we need to gather?)** | 4d? | 2005-03-16 | 2005-03-21 |  |  |  |  | 314d |  |
| 118 | 2.3.1.1 | Develop Standard Products Matrix to compare many versions of standard products. (GIST Draft Taskbook/GIST Course Workbook/PNWCG Product Objectives) | 1d? | 2005-03-16 | 2005-03-16 |  | 2004-12-31 | 2004-12-31 | 1d? | 314d | 0d |
| 119 | 2.3.1.2 | Acquire DPRO Standards and incorporate into above matrix. | 1d? | 2005-03-17 | 2005-03-17 | 118 | 2005-01-03 | 2005-01-03 | 1d? | 314d | 0d |
| 120 | 2.3.1.3 | Need group assistance – there are no members who volunteered for this subgroup. It will need the participation of everyone to work. | 1d? | 2005-03-18 | 2005-03-18 | 119 | 2005-01-04 | 2005-01-04 | 1d? | 314d | 0d |
| 121 | 2.3.1.4 | Provide a final package of Standard Products including definitions and examples. | 1d? | 2005-03-21 | 2005-03-21 | 120 | 2005-01-05 | 2005-01-05 | 1d? | 314d |  |
| 122 | 2.3.2 | **Collect Information** | 3d? | 2005-03-16 | 2005-03-18 |  | 2005-01-06 | 2005-01-10 | 3d? | 310d |  |
| 123 | 2.3.2.1 | Definitions exist in the National Training course workbook for GIST. PNWCG has also created some standard definitions. Compile these into a list for group to review. Cite source. | 1d? | 2005-03-16 | 2005-03-16 |  | 2005-01-06 | 2005-01-06 | 1d? | 310d | 0d |
| 124 | 2.3.2.2 | Review DPRO product definitions and compare to existing definitions for GIST. | 1d? | 2005-03-17 | 2005-03-17 | 123 | 2005-01-07 | 2005-01-07 | 1d? | 310d | 0d |
| 125 | 2.3.2.3 | Collect examples of standard products. | 1d? | 2005-03-18 | 2005-03-18 | 124 | 2005-01-10 | 2005-01-10 | 1d? | 310d | 0d |
| 126 | 2.3.3 | **Conduct Analysis** | 2d? | 2005-03-21 | 2005-03-22 | 125 | 2005-01-11 | 2005-01-12 | 2d? | 310d |  |
| 127 | 2.3.3.1 | Review existing standards definitions (GIST course/PNWCG/DPRO) | 1d? | 2005-03-21 | 2005-03-21 |  | 2005-01-11 | 2005-01-11 | 1d? | 310d | 0d |
| 128 | 2.3.3.2 | Identify discrepancies between groups defining standard and bring these to the larger group for discussion and resolution. There may be specific reasons for discrepancies (Fire Use vs. Type 1) so these should be highlighted for the preliminary package. | 1d? | 2005-03-22 | 2005-03-22 | 127 | 2005-01-12 | 2005-01-12 | 1d? | 310d | 0d |
| 129 | 2.3.4 | **Develop Preliminary Requirements Specifications** | 2d? | 2005-03-23 | 2005-03-24 | 128 | 2005-01-13 | 2005-01-14 | 2d? | 310d |  |
| 130 | 2.3.4.1 | Provide a package of products definitions and samples for group review (GIST/SITL review?) | 1d? | 2005-03-23 | 2005-03-23 |  | 2005-01-13 | 2005-01-13 | 1d? | 310d | 0d |
| 131 | 2.3.4.2 | Find a storage location for GSTOP group review (NIFC site?) | 1d? | 2005-03-24 | 2005-03-24 | 130 | 2005-01-14 | 2005-01-14 | 1d? | 310d | 0d |
| 132 | 2.3.5 | **Review and Validate Requirements** | 1d? | 2005-03-25 | 2005-03-25 | 131 | 2005-01-17 | 2005-01-17 | 1d? | 310d |  |
| 133 | 2.3.5.1 | Decide upon method of acceptance/rejection/modification | 1d? | 2005-03-25 | 2005-03-25 |  | 2005-01-17 | 2005-01-17 | 1d? | 310d |  |
| 134 | 2.3.5.2 | Decide who to get feedback from (GIST 1st, then SITL/PLSC/others?) | 1d? | 2005-03-25 | 2005-03-25 |  | 2005-01-17 | 2005-01-17 | 1d? | 310d |  |
| 135 | 2.3.5.3 | Incorporate feedback into final package of definitions & samples | 1d? | 2005-03-25 | 2005-03-25 |  | 2005-01-17 | 2005-01-17 | 1d? | 310d |  |
| 136 | 2.3.5.4 | Find a permanent storage location for this package? National clearinghouse? | 1d? | 2005-03-25 | 2005-03-25 |  | 2005-01-17 | 2005-01-17 | 1d? | 310d |  |

| ID | WBS | Task | Duration | Start | Finish | Predecessors | Baseline start | Baseline finish | Baseline duration | Total slack | Free slack | Work | Text1 |
| --- | --- | --- | --- | --- | --- | --- | --- | --- | --- | --- | --- | --- | --- |
| 137 | 2.4 | **Incident GIST Minimum Qualifications Requirements** | 5d? | 2005-03-16 | 2005-03-22 |  | 2004-12-31 | 2005-01-06 | 5d? | 313d |  |  |  |
| 138 | 2.4.1 | Define Information Needs (What do we need to gather?) | 1d? | 2005-03-16 | 2005-03-16 |  | 2004-12-31 | 2004-12-31 | 1d? | 313d | 0d |  |  |
| 139 | 2.4.2 | **Perform Information Collection** | 1d? | 2005-03-17 | 2005-03-17 | 138 | 2005-01-03 | 2005-01-03 | 1d? | 313d |  |  |  |
| 140 | 2.4.2.1 | Gather documents and references | 1d? | 2005-03-17 | 2005-03-17 |  | 2005-01-03 | 2005-01-03 | 1d? | 313d | 0d |  |  |
| 141 | 2.4.2.2 | Scan or translate paper documents to electronic format | 1d? | 2005-03-17 | 2005-03-17 |  | 2005-01-03 | 2005-01-03 | 1d? | 316d |  |  |  |
| 142 | 2.4.2.3 | Post documents to disaster help for team review | 1d? | 2005-03-17 | 2005-03-17 |  | 2005-01-03 | 2005-01-03 | 1d? | 316d |  |  |  |
| 143 | 2.4.2.4 | Develop a cross-walk or concise list/format for review | 1d? | 2005-03-17 | 2005-03-17 |  | 2005-01-03 | 2005-01-03 | 1d? | 316d |  |  |  |
| 144 | 2.4.3 | Conduct Analysis | 1d? | 2005-03-18 | 2005-03-18 | 140 | 2005-01-04 | 2005-01-04 | 1d? | 313d | 0d |  |  |
| 145 | 2.4.4 | Develop Preliminary Requirements Specifications | 1d? | 2005-03-21 | 2005-03-21 | 144 | 2005-01-05 | 2005-01-05 | 1d? | 313d | 0d |  |  |
| 146 | 2.4.5 | Review and Validate Requirements | 1d? | 2005-03-22 | 2005-03-22 | 145 | 2005-01-06 | 2005-01-06 | 1d? | 313d |  |  |  |
| 148 | 2.5 | **Incident GIS Minimum Essential Datasets Requirements** | 13d? | 2005-03-15 | 2005-04-01 |  | 2004-12-31 | 2005-01-06 | 5d? | 305d |  | 136h |  |
| 149 | 2.5.1 | Establish MED Sub-Team business practices | 1d? | 2005-03-16 | 2005-03-16 |  |  |  |  | 317d |  |  |  |
| 150 | 2.5.2 | **Develop a MED Sub-team Communication Plan** | 13d? | 2005-03-16 | 2005-04-01 |  | 2004-12-31 | 2005-01-18 | 13d? | 305d |  |  | Communication Plan Document |
| 151 | 2.5.2.1 | **Define ground-rules for Sub-Team (internal) communication** | 7d? | 2005-03-16 | 2005-03-24 |  | 2004-12-31 | 2005-01-10 | 7d? | 305d |  |  | Write Up |
| 152 | 2.5.2.1.1 | Define ground-rules for communication between the MED Sub-Team and other GSTOP Sub-Teams | 1d? | 2005-03-16 | 2005-03-16 |  | 2004-12-31 | 2004-12-31 | 1d? | 305d | 0d |  | Write Up |
| 153 | 2.5.2.1.2 | Define ground rules for communication between the Sub-Team and entities outside of the GSTOP Project | 1d? | 2005-03-17 | 2005-03-17 | 152 | 2005-01-03 | 2005-01-03 | 1d? | 305d | 0d |  | Write Up |
| 154 | 2.5.2.1.3 | Establish a process and schedule for Sub-Team (internal) progress report updates | 1d? | 2005-03-18 | 2005-03-18 | 153 | 2005-01-04 | 2005-01-04 | 1d? | 305d | 0d |  | Write Up |
| 155 | 2.5.2.1.4 | Establish a process and schedule for Sub-Team progress report updates to the GSTOP Team | 1d? | 2005-03-21 | 2005-03-21 | 154 | 2005-01-05 | 2005-01-05 | 1d? | 305d | 0d |  | Write Up |
| 156 | 2.5.2.1.5 | Establish Review Processes | 1d? | 2005-03-22 | 2005-03-22 | 155 | 2005-01-06 | 2005-01-06 | 1d? | 305d | 0d |  | Review Process Document |
| 157 | 2.5.2.1.6 | Establish a process for Sub-Team (internal) review of potential MEDs | 1d? | 2005-03-23 | 2005-03-23 | 156 | 2005-01-07 | 2005-01-07 | 1d? | 305d | 0d |  | Write Up |
| 158 | 2.5.2.1.7 | Establish a process for Sub-Team (internal) review of the draft standard MEDs | 1d? | 2005-03-24 | 2005-03-24 | 157 | 2005-01-10 | 2005-01-10 | 1d? | 305d | 0d |  | Write Up |
| 159 | 2.5.2.2 | **Establish a process for peer reviews** | 2d? | 2005-03-25 | 2005-03-28 | 158 | 2005-01-11 | 2005-01-12 | 2d? | 305d |  |  | Write Up |
| 160 | 2.5.2.2.1 | Establish a process for periodic GSTOP Team reviews | 1d? | 2005-03-25 | 2005-03-25 |  | 2005-01-11 | 2005-01-11 | 1d? | 305d | 0d |  | Write Up |
| 161 | 2.5.2.2.2 | Establish a process for reviewing the final report | 1d? | 2005-03-28 | 2005-03-28 | 160 | 2005-01-12 | 2005-01-12 | 1d? | 305d | 0d |  | Write Up |

| ID | WBS | Task | Duration | Start | Finish | Predecessors | Baseline start | Baseline finish | Baseline duration | Total slack | Free slack | Text1 |
| --- | --- | --- | --- | --- | --- | --- | --- | --- | --- | --- | --- | --- |
| 162 | 2.5.2.3 | **Establish Change processes** | 2d? | 2005-03-29 | 2005-03-30 | 161 | 2005-01-13 | 2005-01-14 | 2d? | 305d |  | Change Process Document |
| 163 | 2.5.2.3.1 | Establish a process for additions/deletions of potential MEDs mid-stream through the Project | 1d? | 2005-03-29 | 2005-03-29 |  | 2005-01-13 | 2005-01-13 | 1d? | 305d | 0d | Write Up |
| 164 | 2.5.2.3.2 | Establish a change process for the additions/deletion of standard MEDs after the final recommendation has been submitted | 1d? | 2005-03-30 | 2005-03-30 | 163 | 2005-01-14 | 2005-01-14 | 1d? | 305d | 0d | Write Up |
| 165 | 2.5.2.4 | **Establish a change process for the additions/deletion of standard MEDs after the final recommendation has been approved through the GSTOP Project** | 1d? | 2005-03-31 | 2005-03-31 | 164 | 2005-01-17 | 2005-01-17 | 1d? | 305d |  | Write Up |
| 166 | 2.5.2.4.1 | Establish MED evaluation methods | 1d? | 2005-03-31 | 2005-03-31 |  | 2005-01-17 | 2005-01-17 | 1d? | 305d | 0d | Evaluation Methodology Document |
| 167 | 2.5.2.5 | Define method for evaluating marker MEDs | 1d? | 2005-04-01 | 2005-04-01 | 166 | 2005-01-18 | 2005-01-18 | 1d? | 305d |  | Write Up |
| 168 | 2.5.2.6 | Define method for evaluating line MEDs | 1d? | 2005-03-16 | 2005-03-16 |  | 2004-12-31 | 2004-12-31 | 1d? | 317d |  | Write Up |
| 169 | 2.5.3 | **Define method for evaluating fill MEDs** | 2d? | 2005-03-16 | 2005-03-17 |  | 2004-12-31 | 2005-01-03 | 2d? | 316d |  | Write Up |
| 170 | 2.5.3.1 | **Conduct a final review of evaluation methods** | 1d? | 2005-03-16 | 2005-03-16 |  | 2004-12-31 | 2004-12-31 | 1d? | 317d |  | Write Up |
| 171 | 2.5.3.1.1 | Define criteria for the acceptance of MEDs as standards | 1d? | 2005-03-16 | 2005-03-16 |  | 2004-12-31 | 2004-12-31 | 1d? | 317d |  | Acceptance Criteria Document |
| 172 | 2.5.3.1.2 | Develop acceptance criteria for marker MEDs | 1d? | 2005-03-16 | 2005-03-16 |  | 2004-12-31 | 2004-12-31 | 1d? | 317d |  | Write Up |
| 173 | 2.5.3.1.3 | Develop acceptance criteria for line MEDs | 1d? | 2005-03-16 | 2005-03-16 |  | 2004-12-31 | 2004-12-31 | 1d? | 317d |  | Write Up |
| 174 | 2.5.3.2 | **Develop acceptance criteria for fill MEDs** | 1d? | 2005-03-16 | 2005-03-16 |  | 2004-12-31 | 2004-12-31 | 1d? | 317d |  | Write Up |
| 175 | 2.5.3.2.1 | Conduct a final review of selection criteria | 1d? | 2005-03-16 | 2005-03-16 |  | 2004-12-31 | 2004-12-31 | 1d? | 317d |  | Write Up |
| 176 | 2.5.3.3 | **Develop a list of MEDs to be evaluated for acceptance as draft standards** | 1d? | 2005-03-16 | 2005-03-16 |  | 2004-12-31 | 2004-12-31 | 1d? | 317d |  | Deliverables |
| 177 | 2.5.3.3.1 | Collect Fire mapping MEDs from the 5 federal fire management agencies (FS, BLM, NPS, FWS, BIA), state agencies, and USGS via the NWCG Geospatial Task Group (GTG) | 1d? | 2005-03-16 | 2005-03-16 |  | 2004-12-31 | 2004-12-31 | 1d? | 317d |  | MED image files |
| 178 | 2.5.3.4 | **Collect Fire mapping MEDs from DHS (FEMA), FAA, and DOD** | 1d? | 2005-03-16 | 2005-03-16 |  | 2004-12-31 | 2004-12-31 | 1d? | 316d |  | MED image files |
| 179 | 2.5.3.4.1 | Document potential sources for additional fire mapping MEDs | 1d? | 2005-03-16 | 2005-03-16 |  | 2004-12-31 | 2004-12-31 | 1d? | 316d | 0d | List of data sources |
| 180 | 2.5.3.5 | Compile MEDs into a single potential MED set | 1d? | 2005-03-17 | 2005-03-17 | 179 | 2005-01-03 | 2005-01-03 | 1d? | 316d |  | Set of potential standard MEDs |
| 181 | 2.5.4 | **Determine the draft standard Raster MEDs** | 1d? | 2005-03-16 | 2005-03-16 |  | 2004-12-31 | 2004-12-31 | 1d? | 317d |  | Deliverables |
| 182 | 2.5.4.1 | **Evaluate each potential marker MED against the marker MED selection criteria** | 1d? | 2005-03-16 | 2005-03-16 |  | 2004-12-31 | 2004-12-31 | 1d? | 317d |  | MED Evaluation Document |
| 183 | 2.5.4.1.1 | Sub-Team selection of the draft standard marker MEDs | 1d? | 2005-03-16 | 2005-03-16 |  | 2004-12-31 | 2004-12-31 | 1d? | 317d |  | Draft list of selected MEDs |
| 184 | 2.5.4.1.2 | Conduct a Sub-team completeness review of the draft standard marker MEDs | 1d? | 2005-03-16 | 2005-03-16 |  | 2004-12-31 | 2004-12-31 | 1d? | 317d |  | Draft Standard Marker MEDs Document |
| 185 | 2.5.4.1.3 | Determine the draft standard Vector MEDs | 1d? | 2005-03-16 | 2005-03-16 |  | 2004-12-31 | 2004-12-31 | 1d? | 317d |  | Deliverables |
| 186 | 2.5.4.2 | Evaluate each potential line MED against the line MED selection criteria | 1d? | 2005-03-16 | 2005-03-16 |  | 2004-12-31 | 2004-12-31 | 1d? | 317d |  | MED Evaluation Document |

| ID | WBS | Task | Type | Duration | Start | Finish | Baseline start | Baseline finish | Baseline duration | Total slack | Resources | Work | Text1 |
| --- | --- | --- | --- | --- | --- | --- | --- | --- | --- | --- | --- | --- | --- |
| 187 | 2.5.4.3 | **Sub-Team selection of the draft standard line MEDs** |  | 1d? | 2005-03-16 | 2005-03-16 | 2004-12-31 | 2004-12-31 | 1d? | 317d |  |  | Draft list of selected MEDs |
| 188 | 2.5.4.3.1 | Conduct a Sub-team completeness review of the draft standard line MEDs |  | 1d? | 2005-03-16 | 2005-03-16 | 2004-12-31 | 2004-12-31 | 1d? | 317d |  |  | Draft Standard Line MEDs Document |
| 189 | 2.5.4.4 | Determine the draft standard Point MEDs |  | 1d? | 2005-03-16 | 2005-03-16 | 2004-12-31 | 2004-12-31 | 1d? | 317d |  |  | Deliverables |
| 190 | 2.5.4.5 | Evaluate each potential fill MED against the fill MED selection criteria |  | 1d? | 2005-03-16 | 2005-03-16 | 2004-12-31 | 2004-12-31 | 1d? | 317d |  |  | MED Evaluation Document |
| 191 | 2.5.4.6 | Sub-Team selection of the draft standard fill MEDs |  | 1d? | 2005-03-16 | 2005-03-16 | 2004-12-31 | 2004-12-31 | 1d? | 317d |  |  | Draft list of selected MEDs |
| 192 | 2.5.5 | Conduct a Sub-team completeness review of the draft standard fill MEDs |  | 1d? | 2005-03-16 | 2005-03-16 | 2004-12-31 | 2004-12-31 | 1d? | 317d | BLM publication shop | 8h | Draft Standard Fill MEDs Document |
| 193 | 2.5.6 | Conduct initial peer review of the draft standard marker, line, and fill MEDs |  | 1d? | 2005-03-16 | 2005-03-16 | 2004-12-31 | 2004-12-31 | 1d? | 317d | GSTOP Team | 8h | Deliverables |
| 194 | 2.5.7 | Prepare draft standard MEDs for initial peer review |  | 1d? | 2005-03-16 | 2005-03-16 | 2004-12-31 | 2004-12-31 | 1d? | 317d |  |  | Initial Peer Review Package |
| 195 | 2.5.8 | Submit the draft standard MEDs to the 5 federal fire management agencies, State agencies, and USGS via the NWCG Geospatial Task Group (GTG); and to DHS (FEMA), FAA, DOD, and GSTOP Team for peer review | milestone | 0d | 2005-03-15 | 2005-03-15 | 2004-12-31 | 2004-12-31 | 0d | 318d |  |  | Submission Report |
| 196 | 2.5.9 | Review feedback of initial peer review |  | 1d? | 2005-03-16 | 2005-03-16 | 2004-12-31 | 2004-12-31 | 1d? | 317d |  |  | Initial Peer Review Document |
| 197 | 2.5.10 | **Identify required changes to draft standard MEDs based on the initial peer review feedback** |  | 1d? | 2005-03-15 | 2005-03-16 | 2005-01-18 | 2005-01-19 | 1d? | 317d |  | 120h | List of required MED changes |
| 198 | 2.5.10.1 | **Make required changes, as identified, to draft standard MEDs** |  | 1d? | 2005-03-16 | 2005-03-16 | 2005-01-19 | 2005-01-19 | 1d? | 317d |  | 24h | Initial updated MEDs list |
| 199 | 2.5.10.1.1 | Conduct final peer review of the draft standard marker, line, and fill MEDs |  | 1d? | 2005-03-16 | 2005-03-16 | 2005-01-19 | 2005-01-19 | 1d? | 317d | NWCG Training Team | 8h | Deliverables |
| 200 | 2.5.10.1.2 | Prepare draft standard MEDs for final peer review |  | 1d? | 2005-03-16 | 2005-03-16 | 2005-01-19 | 2005-01-19 | 1d? | 317d | Victoria; ; deb epps | 16h | Final Peer Review Package |
| 201 | 2.5.10.2 | **Submit the draft standard MEDs to the 5 federal fire management agencies and State agencies via the NWCG Geospatial Task Group (GTG); and to the HSA (FEMA), FAA, DOD, and GSTOP Team for peer review** |  | 1d? | 2005-03-16 | 2005-03-16 | 2005-01-19 | 2005-01-19 | 1d? | 317d | subteam(s) | 32h | Submission Report |
| 202 | 2.5.10.2.1 | Review feedback of the final peer review |  | 1d? | 2005-03-16 | 2005-03-16 | 2005-01-19 | 2005-01-19 | 1d? | 317d | subteam(s) | 8h | Final Peer Review Document |
| 203 | 2.5.10.2.2 | Identify required changes to draft standard MEDs based on the final peer review feedback |  | 1d? | 2005-03-16 | 2005-03-16 | 2005-01-19 | 2005-01-19 | 1d? | 317d | subteam(s) | 8h | List of required MED changes |
| 204 | 2.5.10.2.3 | Make required changes, as identified, to draft standard MEDs |  | 1d? | 2005-03-16 | 2005-03-16 | 2005-01-19 | 2005-01-19 | 1d? | 317d | subteam(s) | 8h | final updated MEDs list |
| 205 | 2.5.10.2.4 | Ratification of the final draft standard MEDs by the Sub-Team |  | 1d? | 2005-03-16 | 2005-03-16 | 2005-01-19 | 2005-01-19 | 1d? | 317d |  |  | Final Draft Standard MEDs List |
| 206 | 2.5.10.3 | **Finalize recommendation of standard Fire Mapping MEDs** |  | 1d? | 2005-03-16 | 2005-03-16 | 2005-01-19 | 2005-01-19 | 1d? | 317d |  | 40h | Deliverables |
| 207 | 2.5.10.3.1 | Create a report recommending the adoption of the draft standard MEDs |  | 1d? | 2005-03-16 | 2005-03-16 | 2005-01-19 | 2005-01-19 | 1d? | 317d | GSTOP Team | 8h | Recommendation Report |
| 208 | 2.5.10.3.2 | Conduct a Sub-Team review of the report |  | 1d? | 2005-03-16 | 2005-03-16 | 2005-01-19 | 2005-01-19 | 1d? | 317d |  |  | Finalized Recommendation Report |
| 209 | 2.5.10.3.3 | Submit the report to GSTOP-PM |  | 1d? | 2005-03-16 | 2005-03-16 | 2005-01-19 | 2005-01-19 | 1d? | 317d |  |  | Report Submission |
| 210 | 2.5.10.3.4 | Review and Validate draft SOP’s for completeness |  | 0.5d? | 2005-03-16 | 2005-03-16 | 2005-01-19 | 2005-01-19 | 0.5d? | 317.5d | GSTOP Team; GTG; GTAG; some other reviewers | 8h |  |
| 211 | 2.5.10.3.5 | Review and Validate draft SOP’s for GIS content |  | 1d? | 2005-03-16 | 2005-03-16 | 2005-01-19 | 2005-01-19 | 1d? | 317d | GSTOP Team; GTAG; somes other reviewers | 8h |  |
| 212 | 2.5.10.3.6 | consolidate reviewers inputs |  | 1d? | 2005-03-16 | 2005-03-16 | 2005-01-19 | 2005-01-19 | 1d? | 317d |  |  |  |
| 213 | 2.5.10.3.7 | Evaluate Feedback for inclusion in SOP revision |  | 1d? | 2005-03-16 | 2005-03-16 | 2005-01-19 | 2005-01-19 | 1d? | 317d | GSTOP Team; Indepdent reviewer | 8h |  |
| 214 | 2.5.10.3.8 | Incorporate accepted feedback from reviewers |  | 1d? | 2005-03-16 | 2005-03-16 | 2005-01-19 | 2005-01-19 | 1d? | 317d | subteams | 8h | Revised Draft SOPs |

| ID | WBS | Task | Type | Duration | Start | Finish | Baseline start | Baseline finish | Baseline duration | Total slack | Constraint | Resources | Work |
| --- | --- | --- | --- | --- | --- | --- | --- | --- | --- | --- | --- | --- | --- |
| 215 | 2.5.10.4 | **Agencies' review of Draft SOPs** |  | 1d? | 2005-03-16 | 2005-03-16 | 2005-01-19 | 2005-01-19 | 1d? | 317d |  | all concerned/impacted parties | 16h |
| 216 | 2.5.10.4.1 | Create a cover letter, and response process |  | 1d? | 2005-03-16 | 2005-03-16 | 2005-01-19 | 2005-01-19 | 1d? | 317d |  |  |  |
| 217 | 2.5.10.4.2 | Review and Validate draft SOP’s |  | 1d? | 2005-03-16 | 2005-03-16 | 2005-01-19 | 2005-01-19 | 1d? | 317d |  | NWCG member agencies | 8h |
| 218 | 2.5.10.4.3 | Evaluate Feedback for inclusion in SOP revision |  | 1d? | 2005-03-16 | 2005-03-16 | 2005-01-19 | 2005-01-19 | 1d? | 317d |  |  |  |
| 219 | 2.5.10.4.4 | Incorporate Feedback from reviewers |  | 1d? | 2005-03-16 | 2005-03-16 | 2005-01-19 | 2005-01-19 | 1d? | 317d |  |  |  |
| 220 | 2.5.10.5 | Develop GSTOP Change Management Plan |  | 1d? | 2005-03-16 | 2005-03-16 | 2005-01-19 | 2005-01-19 | 1d? | 317d |  |  |  |
| 221 | 2.5.10.6 | Review GSTOP Change Management Plan |  | 1d? | 2005-03-16 | 2005-03-16 | 2005-01-19 | 2005-01-19 | 1d? | 317d |  | GTG Exec Comm | 8h |
| 222 | 2.5.10.7 | PRELIMINARY GIS SOP’s READY FOR FIELD TESTING | milestone | 0d | 2005-03-15 | 2005-03-15 | 2005-01-18 | 2005-01-18 | 0d | 318d | start no earlier than 2005-01-18 |  |  |
| 223 | 2.6 | **Incident GIS Standard Data Sharing and Archiving Standards (02-08-2005)** |  | 1d? | 2005-03-16 | 2005-03-16 |  |  |  | 317d |  |  |  |
| 224 | 2.6.1 | Define Information Needs (What do we need to gather?) |  | 1d? | 2005-03-16 | 2005-03-16 |  |  |  | 317d |  |  |  |
| 225 | 2.6.1.1 | Compile existing archiving standards in use (e.g. data format, transfer mode) |  | 1d? | 2005-03-16 | 2005-03-16 |  |  |  | 317d |  |  |  |
| 226 | 2.6.1.2 | Identify how archiving is done at present time by ICS, military, other incident responders, project-management |  | 1d? | 2005-03-16 | 2005-03-16 |  |  |  | 317d |  |  |  |
| 227 | 2.6.1.3 | Gather NARA, Records Management requirements (review policies, lawsuits) e.g. physical location, acceptable media, supporting documentation |  | 1d? | 2005-03-16 | 2005-03-16 |  |  |  | 317d |  |  |  |
| 228 | 2.6.1.4 | Determine the least common denominator (shapefile) or possibility of multiple formats |  | 1d? | 2005-03-16 | 2005-03-16 |  |  |  | 317d |  |  |  |
| 229 | 2.6.2 | **Collect Information** |  | 1d? | 2005-03-16 | 2005-03-16 |  |  |  | 317d |  |  |  |
| 230 | 2.6.2.1 | Conduct literature review |  | 1d? | 2005-03-16 | 2005-03-16 |  |  |  | 317d |  |  |  |
| 231 | 2.6.3 | **Conduct Analysis** |  | 1d? | 2005-03-16 | 2005-03-16 |  |  |  | 317d |  |  |  |
| 232 | 2.6.3.1 | Compile, Synthesize requirements |  | 1d? | 2005-03-16 | 2005-03-16 |  |  |  | 317d |  |  |  |
| 233 | 2.6.4 | **Develop Preliminary Requirements Specifications** |  | 1d? | 2005-03-16 | 2005-03-16 |  |  |  | 317d |  |  |  |
| 234 | 2.6.4.2 | Proposal of SOP |  | 1d? | 2005-03-16 | 2005-03-16 |  |  |  | 317d |  |  |  |
| 235 | 2.6.5 | **Review and Validate Requirements** |  | 1d? | 2005-03-16 | 2005-03-16 |  |  |  | 317d |  |  |  |
| 236 | 2.6.5.1 | Sub-Team Review of SOP |  | 1d? | 2005-03-16 | 2005-03-16 |  |  |  | 317d |  |  |  |
| 237 | 2.6.5.2 | Revise, Edit Proposed SOP |  | 1d? | 2005-03-16 | 2005-03-16 |  |  |  | 317d |  |  |  |
| 238 | 2.6.5.3 | Submit to Project Manager for Team Review |  | 1d? | 2005-03-16 | 2005-03-16 |  |  |  | 317d |  |  |  |

Notes:
- 225: Text1: GTG standards committee,Mary Kwart
- 226: Text1: Internet Search,Military,etc.,survey GISTs,Plans Sections (Mary Kwart),Documents Sections
- 227: Text1: Business Lead,FGDC,NARA,agency guidance
- 228: Text1: TBD
- 230: Text1: FGDC,GeoMAC,NPS I&M,NPS Focus,NARA
- 234: Text1: Sub-Team
- 236: Text1: Sub-Team
- 237: Text1: Sub-Team

| ID | WBS | Task | Duration | Start | Finish | Total slack | Text1 |
| --- | --- | --- | --- | --- | --- | --- | --- |
| 240 | 2.7 | **Incident GIS Standard Documentation and Archiving** | 1d? | 2005-03-16 | 2005-03-16 | 317d |  |
| 241 | 2.7.1 | **Incident GIS Standard Documentation and Archiving Procedures** | 1d? | 2005-03-16 | 2005-03-16 | 317d |  |
| 242 | 2.7.1.1 | Identify hierarchy of archive needs (incident, land unit, agency, NARA) | 1d? | 2005-03-16 | 2005-03-16 | 317d |  |
| 243 | 2.7.1.2 | Compile procedures currently in use | 1d? | 2005-03-16 | 2005-03-16 | 317d |  |
| 244 | 2.7.1.3 | Identify if existing procedures in use "somewhere out there" may be acceptible (e.g. NARA) | 1d? | 2005-03-16 | 2005-03-16 | 317d |  |
| 245 | 2.7.2 | Collect Information | 1d? | 2005-03-16 | 2005-03-16 | 317d |  |
| 246 | 2.7.2.1 | Identify test procedures for documentation and archiving | 1d? | 2005-03-16 | 2005-03-16 | 317d |  |
| 247 | 2.7.3 | Conduct Analysis | 1d? | 2005-03-16 | 2005-03-16 | 317d |  |
| 248 | 2.7.3.1 | Test and identify strengths/weaknesses of existing procedures | 1d? | 2005-03-16 | 2005-03-16 | 317d |  |
| 249 | 2.7.4 | Develop Preliminary Requirements Specifications | 1d? | 2005-03-16 | 2005-03-16 | 317d |  |
| 250 | 2.7.4.1 | Prepare recommendations | 1d? | 2005-03-16 | 2005-03-16 | 317d |  |
| 251 | 2.7.5 | Review and Validate Requirements | 1d? | 2005-03-16 | 2005-03-16 | 317d |  |
| 253 | 2.8 | **Incident GIS Transition Procedures** | 1d? | 2005-03-16 | 2005-03-16 | 317d |  |
| 254 | 2.8.1 | **Define Information Needs (What do we need to gather?)** | 1d? | 2005-03-16 | 2005-03-16 | 317d |  |
| 255 | 2.8.1.1 | Determine "universe" of transitions: (team to team); (team to unit); (team to archive) | 1d? | 2005-03-16 | 2005-03-16 | 317d | Business Lead,FGDC,NARA,agency guidance |
| 256 | 2.8.1.2 | Compile procedures currently in use | 1d? | 2005-03-16 | 2005-03-16 | 317d | Other "team" environs (e.g. military),survey? Mary Kwart? |
| 257 | 2.8.1.3 | Identify if existing procedures in use "somewhere out there" may be acceptible (e.g. NARA) | 1d? | 2005-03-16 | 2005-03-16 | 317d | Sub-Team |
| 258 | 2.8.2 | Evaluate Procedures | 1d? | 2005-03-16 | 2005-03-16 | 317d |  |
| 259 | 2.8.2.1 | Identify test procedures for documentation and archiving | 1d? | 2005-03-16 | 2005-03-16 | 317d | Sub-Team |
| 260 | 2.8.3 | **Conduct Analysis** | 1d? | 2005-03-16 | 2005-03-16 | 317d |  |
| 261 | 2.8.3.1 | Test and identify strengths/weaknesses of existing procedures | 1d? | 2005-03-16 | 2005-03-16 | 317d | Sub-Team,field teams |
| 262 | 2.8.4 | **Develop Preliminary Requirements Specifications** | 1d? | 2005-03-16 | 2005-03-16 | 317d |  |
| 263 | 2.8.4.1 | Prepare recommendations | 1d? | 2005-03-16 | 2005-03-16 | 317d |  |
| 264 | 2.8.5 | **Review and Validate Requirements** | 1d? | 2005-03-16 | 2005-03-16 | 317d |  |
| 265 | 2.8.5.1 | Sub-Team Review of SOP | 1d? | 2005-03-16 | 2005-03-16 | 317d | Sub-Team |
| 266 | 2.8.5.2 | Revise, Edit Proposed SOP | 1d? | 2005-03-16 | 2005-03-16 | 317d | Sub-Team |
| 267 | 2.8.6 | Submit to Project Manager for Team Review | 1d? | 2005-03-16 | 2005-03-16 | 317d |  |

| ID | WBS | Task | Duration | Start | Finish | Total slack | Resources | Work |
| --- | --- | --- | --- | --- | --- | --- | --- | --- |
| 269 | 3 | **Draft Incident GIS SOPs** | 1d? | 2004-12-01 | 2004-12-01 | 392d | GSTOP Team | 8h |
| 270 | 3.1 | Develop template for GIS SOPs | 1d? | 2004-12-01 | 2004-12-01 | 392d |  |  |
| 271 | 3.2 | Define Information Needs (What do we need to gather?) | 1d? | 2004-12-01 | 2004-12-01 | 392d |  |  |
| 272 | 3.3 | Collect Information | 1d? | 2004-12-01 | 2004-12-01 | 392d |  |  |
| 273 | 3.4 | Conduct Analysis | 1d? | 2004-12-01 | 2004-12-01 | 392d |  |  |
| 274 | 3.5 | Develop Preliminary SOP’s | 1d? | 2004-12-01 | 2004-12-01 | 392d |  |  |
| 275 | 3.6 | Review and Validate draft SOP’s | 1d? | 2004-12-01 | 2004-12-01 | 392d |  |  |
| 276 | 3.7 | Incorporate Feedback from reviewers | 1d? | 2004-12-01 | 2004-12-01 | 392d |  |  |
| 277 | 3.8 | Develop GSTOP Change Management Plan | 1d? | 2004-12-01 | 2004-12-01 | 392d |  |  |
| 278 | 3.9 | Review GSTOP Change Management Plan | 1d? | 2004-12-01 | 2004-12-01 | 392d |  |  |
| 279 | 3.10 | PRELIMINARY GIS SOP’s READY FOR FIELD TESTING | 1d? | 2004-12-01 | 2004-12-01 | 392d |  |  |
| 280 | 4 | **Incident GIS SOPs Field Test** | 1d? | 2004-12-01 | 2004-12-01 | 392d | IMT Teams | 8h |
| 281 | 4.1 | Develop Quality Assurance and Field Test Plan | 1d? | 2004-12-01 | 2004-12-01 | 392d |  |  |
| 282 | 4.1.1 | develop questionnaire | 1d? | 2004-12-01 | 2004-12-01 | 392d |  |  |
| 283 | 4.2 | Execute Quality Assurance and Field Test Plan | 1d? | 2004-12-01 | 2004-12-01 | 392d |  |  |
| 284 | 4.2.1 | collect written/survey results from the field test | 1d? | 2004-12-01 | 2004-12-01 | 392d |  |  |
| 285 | 4.2.2 | conduct interviews with GISTs to measure success of Draft SOPs | 1d? | 2004-12-01 | 2004-12-01 | 392d |  |  |
| 286 | 4.2.3 | conduct interviews with SIT Unit Leaders to measure success of Draft SOPs | 1d? | 2004-12-01 | 2004-12-01 | 392d |  |  |
| 287 | 4.3 | Analyze Quality Assurance and Field Test Plan Results | 1d? | 2004-12-01 | 2004-12-01 | 392d |  |  |
| 288 | 4.4 | Ensure requirements are reviewed and tested by business community | 1d? | 2004-12-01 | 2004-12-01 | 392d |  |  |
| 289 | 5 | **Final Incident GIS SOPs** | 1d? | 2004-12-01 | 2004-12-01 | 392d | GSTOP Team | 8h |
| 290 | 5.1 | Analyze feedback on Incident GIS SOPs | 1d? | 2004-12-01 | 2004-12-01 | 392d |  |  |
| 291 | 5.2 | Update and finalize Incident GIS SOPs | 1d? | 2004-12-01 | 2004-12-01 | 392d |  |  |
| 292 | 5.3 | Deliver Final Incident GIS SOPs to Executive Committee | 1d? | 2004-12-01 | 2004-12-01 | 392d |  |  |
| 293 | 5.4 | Deliver Final Incident GIS SOPs to Incident Based Automation Project | 1d? | 2004-12-01 | 2004-12-01 | 392d |  |  |

| ID | WBS | Task | Duration | Start | Finish | Total slack | Constraint | Resources | Work |
| --- | --- | --- | --- | --- | --- | --- | --- | --- | --- |
| 294 | 6 | **GSTOP Project Closeout** | 393d? | 2004-12-01 | 2006-06-02 | 0d |  | GTG Exec Comm | 3144h |
| 295 | 6.1 | Prepare GSTOP Team Recommendations | 1d? | 2004-12-01 | 2004-12-01 | 392d |  |  |  |
| 296 | 6.2 | Document Lessons Learned | 1d? | 2004-12-01 | 2004-12-01 | 392d |  |  |  |
| 297 | 6.3 | GSTOP PROJECT TEAM RELEASED | 1d? | 2006-06-02 | 2006-06-02 | 0d | finish no earlier than 2006-06-02 |  |  |
